# PRODUCTIE SCHEMA RUWBOUW kantoorgebouw

Schedule from MS Project, 2004-06-01 to 2005-04-25, status date 2003-06-02.
BAM Nelissen Van Egteren

## Calendars

- ruwbouw kalender: Mon-Fri 08:30-12:30, 13:00-17:00; Sat-Sun off. Exceptions (off unless hours are given): 2004-06-11, 2004-07-09, 2004-07-19 to 2004-07-23, 2004-07-26 to 2004-07-30, 2004-08-02 to 2004-08-06, 2004-08-20, 2004-08-27, 2004-09-03, 2004-09-17, 2004-09-24, 2004-10-01, 2004-10-15, 2004-10-29, 2004-11-05, 2004-11-12, 2004-11-19, 2004-12-03, 2004-12-10, 2004-12-17, 2004-12-20 to 2004-12-24, 2004-12-27 to 2004-12-31, 2005-01-03 to 2005-01-07, 2005-01-14, 2005-02-03 to 2005-02-04, 2005-02-07 to 2005-02-08, 2005-02-11, 2005-02-17 to 2005-02-18, 2005-02-25, 2005-03-04, 2005-03-18, 2005-03-28, 2005-04-01, 2005-04-15.

## Resources

| Resource |
| --- |
| beg.grond |
| 1e verd |
| 2e verd |
| 3e verd |
| 4e verd |
| 1e verd,vloer |
| 2e verd,vloer |
| 3e verd,vloer |
| 4e verd,vloer |
| dakvloer |

## Schedule

| ID | WBS | Task | Duration | Start | Finish | Predecessors | Total slack | Free slack | Constraint | Resources | Work | Text1 |
| --- | --- | --- | --- | --- | --- | --- | --- | --- | --- | --- | --- | --- |
| 1 | 1 | **AANLOOP FASE** | 20d | 2004-06-01 | 2004-06-29 |  | 0d |  |  |  |  |  |
| 2 | 1.1 | bouwplaats inrichten containers | 6d | 2004-06-01 | 2004-06-08 |  | 0d |  |  |  |  | st |
| 3 | 1.2 | bouwplaats installaties aanleg | 6d | 2004-06-03 | 2004-06-10 | 2SS+2d | 0d |  |  |  |  | m1 |
| 4 | 1.3 | bouwput ontgraven incl.uitzetten | 5d | 2004-06-08 | 2004-06-15 | 3SS+3d | 0d |  |  |  |  | m3 |
| 5 | 1.4 | paalfundatie prefab palen heien | 5d | 2004-06-16 | 2004-06-22 | 4SS+5d | 0d |  |  |  |  | st |
| 6 | 1.5 | paalfundatie paalkoppen snellen | 2d | 2004-06-23 | 2004-06-24 | 5 | 0d |  |  |  |  | st |
| 7 | 1.6 | bouwkraan + kraanbaan montage | 5d | 2004-06-23 | 2004-06-29 | 5 | 155d |  |  |  |  | m1 |
| 9 | 2 | **ONDERBOUWFASE** | 15d | 2004-06-25 | 2004-07-16 |  | 0d |  |  | 4e verd,vloer | 128h |  |
| 10 | 2.1 | funderingsbalken kist+wap+beton | 10d | 2004-06-25 | 2004-07-08 | 6 | 0d |  |  |  |  | m1 |
| 11 | 2.2 | funderingspoeren kist+wap+beton | 6d | 2004-07-01 | 2004-07-08 | 6SS+6d | 148d |  |  |  |  | st |
| 12 | 2.3 | funderingsvloer onder kruipruimte | 4d | 2004-07-01 | 2004-07-06 | 10SS+4d | 144d | 0d |  |  |  | m2 |
| 13 | 2.4 | riolering in kruipruimte | 3d | 2004-07-07 | 2004-07-12 | 12 | 144d | 0d |  |  |  | m1 |
| 14 | 2.5 | systeemvloer boven kruipruimte | 4d | 2004-07-12 | 2004-07-15 | 13SS+2d | 144d |  |  |  |  | m2 |
| 15 | 2.6 | BEG,GROND VLOER zand | 3d | 2004-06-30 | 2004-07-02 | 10SS+3d | 0d |  |  |  |  | m3 |
| 16 | 2.7 | werkvloer beton | 2d | 2004-07-05 | 2004-07-06 | 15 | 0d |  |  |  |  | m2 |
| 17 | 2.8 | wapening vlechten | 5d | 2004-07-07 | 2004-07-14 | 16 | 0d |  |  |  |  | ton |
| 18 | 2.9 | beton storten beg.grond vloer | 2d | 2004-07-13 | 2004-07-16 | 17SS+3d | 0d |  |  |  |  | m3 |
| 20 | 3 | **BOVENBOUW FASE** | 82d | 2004-08-09 | 2005-01-10 |  | 0d |  |  |  | 120h |  |
| 21 | 3.1 | betonwanden kist+wap+beton | 70.42d | 2004-08-09 | 2004-12-08 | 18SS+4d | 0d |  |  |  |  | st |
| 22 | 3.2 | middenkolommen kist+wap+beton | 70.42d | 2004-08-09 | 2004-12-09 | 21SS | 0d |  |  |  |  | st |
| 23 | 3.3 | gevelkolommen kist+wap+beton | 69.31d | 2004-08-09 | 2004-12-08 | 22SS | 0d |  |  |  |  | st |
| 24 | 3.4 | prefab gevelbalken stellen | 69.64d | 2004-08-11 | 2004-12-13 | 23SS+2d | 0d |  |  |  |  | st |
| 25 | 3.5 | 1e VERD,VLOER bekisten | 15d | 2004-08-16 | 2004-09-08 | 24SS+3d | 0d |  |  |  |  | m2 |
| 26 | 3.6 | vloerwapening vlechten | 14d | 2004-08-19 | 2004-09-10 | 25SS+3d | 120d | 0d |  |  |  | ton |
| 27 | 3.7 | vloer betonstorten veld L- M- R | 3d | 2004-08-30 | 2004-09-13 | 26SS+5d | 120d |  | start no earlier than 2004-08-29 | 1e verd,vloer | 24h | m3 |
| 28 | 3.8 | 2e VERD,VLOER bekisten | 15d | 2004-09-09 | 2004-10-04 | 25 | 0d |  |  |  |  | m2 |
| 29 | 3.9 | vloer wapening vlechten | 14d | 2004-09-14 | 2004-10-06 | 28SS+3d | 104d | 0d |  |  |  | ton |
| 30 | 3.10 | vloer beton storten veld L- M- R | 3d | 2004-09-23 | 2004-10-07 | 29SS+6d | 104d |  |  | 2e verd,vloer | 24h | m3 |
| 31 | 3.11 | 3e VERD,VLOER - bekisten | 15d | 2004-10-05 | 2004-10-26 | 28 | 0d |  |  |  |  | m2 |
| 32 | 3.12 | vloer wapening vlechten | 14d | 2004-10-08 | 2004-10-28 | 31SS+3d | 90d | 0d |  |  |  | ton |
| 33 | 3.13 | vloer beton storten veld L- M- R | 3d | 2004-10-15 | 2004-10-29 | 32SS+5d | 90d |  | start no earlier than 2004-10-14 | 3e verd,vloer | 24h | m3 |
| 34 | 3.14 | 4e VERD,VLOER bekisten | 15d | 2004-10-27 | 2004-11-22 | 31 | 0d |  |  |  |  | m2 |
| 35 | 3.15 | vloer wapening vlechten | 14d | 2004-11-02 | 2004-11-24 | 34SS+3d | 49d | 0d |  |  |  | ton |
| 36 | 3.16 | vloer beton storten veld L- M- R | 3d | 2004-11-11 | 2004-11-25 | 35SS+6d | 49d | 0d |  | 4e verd,vloer | 24h | m3 |
| 37 | 3.17 | DAKVLOER bekisten | 15d | 2004-11-23 | 2004-12-15 | 34 | 0d |  |  |  |  | m2 |
| 38 | 3.18 | vloer wapening vlechten | 14d | 2004-11-26 | 2005-01-10 | 37SS+3d | 0d |  |  |  |  | ton |
| 39 | 3.19 | dakvloer beton storten veld L- M- R | 3d | 2004-12-03 | 2004-12-17 | 38SS+5d | 0d |  |  | dakvloer | 24h | m3 |

| ID | WBS | Task | Type | Duration | Start | Finish | Predecessors | Total slack | Free slack | Text1 |
| --- | --- | --- | --- | --- | --- | --- | --- | --- | --- | --- |
| 41 | 4 | **GEVEL + DAK FASE** |  | 75d | 2004-11-26 | 2005-04-25 |  | 0d |  |  |
| 42 | 4.1 | dakopbouw staalconstructie |  | 4d | 2005-01-10 | 2005-01-13 | 39 | 43d | 0d | m2 |
| 43 | 4.2 | dakopbouw beplating gevel/dak |  | 5d | 2005-01-17 | 2005-01-21 | 42 | 43d | 0d | m2 |
| 44 | 4.3 | dakbedekking incl. isolatie |  | 10d | 2005-01-24 | 2005-02-10 | 43 | 43d | 0d | m2 |
| 45 | 4.4 | dak wind+ waterdicht | milestone | 0d | 2005-01-28 | 2005-01-28 | 44SS+5d | 48d |  |  |
| 46 | 4.5 | **gevel linkervleugel** |  | 50d | 2004-11-26 | 2005-03-15 |  | 8d |  |  |
| 47 | 4.5.1 | stelkozijnen van binnen stellen |  | 10d | 2004-11-26 | 2004-12-13 | 36 | 50d | 0d | st |
| 48 | 4.5.2 | metselen binnen borstwering |  | 10d | 2004-12-06 | 2005-01-11 | 47SS+5d | 60d |  | m2 |
| 49 | 4.5.3 | gevelsteiger monteren |  | 24d | 2004-12-09 | 2005-02-10 | 39SS+3d | 0d |  | m2 |
| 50 | 4.5.4 | metselen buitenspouwblad |  | 25d | 2004-12-14 | 2005-02-16 | 49SS+2d | 0d |  | m2 |
| 51 | 4.5.5 | alu gevelkozijnen stellen |  | 10d | 2005-02-21 | 2005-03-08 | 50 | 25d | 0d | st |
| 52 | 4.5.6 | glas plaatsen in alu kozijnen |  | 5d | 2005-03-09 | 2005-03-15 | 51 | 25d | 0d | st |
| 53 | 4.5.7 | linkervleugel waterdicht | milestone | 0d | 2005-03-15 | 2005-03-15 | 52 | 25d |  |  |
| 54 | 4.6 | **gevel rechtervleugel** |  | 65d | 2004-12-14 | 2005-04-25 |  | 0d |  |  |
| 55 | 4.6.1 | stelkozijnen van binnen stellen |  | 10d | 2004-12-14 | 2005-01-19 | 47 | 50d | 0d | st |
| 56 | 4.6.2 | metselen binnen borstwering |  | 10d | 2005-01-12 | 2005-01-26 | 55SS+5d | 50d |  | m2 |
| 57 | 4.6.3 | gevelsteiger monteren |  | 24d | 2005-02-14 | 2005-03-24 | 49 | 19d |  | m2 |
| 58 | 4.6.4 | metselen buitenspouwblad |  | 25d | 2005-02-21 | 2005-03-31 | 50 | 0d |  | m2 |
| 59 | 4.6.5 | alu gevelkozijnen stellen |  | 10d | 2005-04-04 | 2005-04-18 | 58 | 0d |  | st |
| 60 | 4.6.6 | glas plaatsen in alu kozijnen |  | 5d | 2005-04-19 | 2005-04-25 | 59 | 0d |  | st |
| 61 | 4.6.7 | rechtervleugel waterdicht | milestone | 0d | 2005-04-25 | 2005-04-25 | 60 | 0d |  |  |
